# Projet centre Municipal Ecully

Schedule from MS Project, 2026-03-09 to 2029-03-30, 7 hours a day.

## Calendars

- Standard: Mon-Fri 09:00-12:00, 14:00-18:00; Sat-Sun off.

## Schedule

| ID | WBS | Task | Duration | Start | Finish | Predecessors | Total slack | Constraint |
| --- | --- | --- | --- | --- | --- | --- | --- | --- |
| 1 | 1 | **CHU Montpellier - Internat** | 800d | 2026-03-09 | 2029-03-30 |  | 0d |  |
| 2 | 1.1 | **Phase 3 - Consultation Concessionnaires (12 mois)** | 267d | 2026-03-09 | 2027-03-16 |  | 0d |  |
| 3 | 1.1.1 | Appel à Candidatures | 40d | 2026-03-09 | 2026-05-01 |  | 0d | start no earlier than 2026-03-09 |
| 4 | 1.1.2 | Reception Candidatures | 1d | 2026-05-04 | 2026-05-04 | 3 | 0d |  |
| 5 | 1.1.3 | Analyse candidatures | 20d | 2026-05-05 | 2026-06-01 | 4 | 0d |  |
| 6 | 1.1.4 | Choix candidats | 5d | 2026-06-02 | 2026-06-08 | 5 | 0d |  |
| 7 | 1.1.5 | Invitation à soumissionner aux Candidats retenus | 60d | 2026-06-09 | 2026-08-31 | 6 | 0d |  |
| 8 | 1.1.6 | Visite de site | 1d | 2026-07-01 | 2026-07-01 |  | 717d | start no earlier than 2026-07-01 |
| 9 | 1.1.7 | Reception Offres intiales | 1d | 2026-09-01 | 2026-09-01 | 7 | 0d |  |
| 10 | 1.1.8 | Analyse des Offres initiales | 20d | 2026-09-02 | 2026-09-29 | 9 | 0d |  |
| 11 | 1.1.9 | Négociation Phase 1 | 10d | 2026-09-30 | 2026-10-13 | 10 | 0d |  |
| 12 | 1.1.10 | Demande des offres améliorées | 5d | 2026-10-14 | 2026-10-20 | 11 | 0d |  |
| 13 | 1.1.11 | Réception des offres améliorées | 30d | 2026-10-21 | 2026-12-01 | 12 | 0d |  |
| 14 | 1.1.12 | Analyse des offres améliorées | 20d | 2026-12-02 | 2026-12-29 | 13 | 0d |  |
| 15 | 1.1.13 | Négociation Phase 2 | 10d | 2026-12-30 | 2027-01-12 | 14 | 0d |  |
| 16 | 1.1.14 | Demande des offres finales | 5d | 2027-01-13 | 2027-01-19 | 15 | 0d |  |
| 17 | 1.1.15 | Réception des offres finales | 20d | 2027-01-20 | 2027-02-16 | 16 | 0d |  |
| 18 | 1.1.16 | Analyse des offres finales | 10d | 2027-02-17 | 2027-03-02 | 17 | 0d |  |
| 19 | 1.1.17 | Négociation avec l'attributaire ressenti | 5d | 2027-03-03 | 2027-03-09 | 18 | 0d |  |
| 20 | 1.1.18 | Choix du Concessionnaire et notification du marché | 5d | 2027-03-10 | 2027-03-16 | 19 | 0d |  |
| 21 | 1.2 | **Phase 4 - Suivi des etudes de conception (réalisées par le Concessionnaire) (9 mois)** | 197d | 2027-03-17 | 2027-12-16 |  | 0d |  |
| 22 | 1.2.1 | Etudes AVP/PC | 40d | 2027-03-17 | 2027-05-11 | 20 | 0d |  |
| 23 | 1.2.2 | Reception AVP/PC | 1d | 2027-05-12 | 2027-05-12 | 22 | 0d |  |
| 24 | 1.2.3 | Avis sur AVP / PC | 15d | 2027-05-13 | 2027-06-02 | 23 | 0d |  |
| 25 | 1.2.4 | Etudes PRO | 70d | 2027-06-03 | 2027-09-08 | 24 | 0d |  |
| 26 | 1.2.5 | Reception PRO | 1d | 2027-09-09 | 2027-09-09 | 25 | 0d |  |
| 27 | 1.2.6 | Avis sur PRO | 15d | 2027-09-10 | 2027-09-30 | 26 | 0d |  |
| 28 | 1.2.7 | Phase Appel d'offres travaux et choix des entreprises (par le concessionnaire) | 55d | 2027-10-01 | 2027-12-16 | 27 | 0d |  |

| ID | WBS | Task | Duration | Start | Finish | Predecessors | Total slack |
| --- | --- | --- | --- | --- | --- | --- | --- |
| 29 | 1.3 | **Phase 5 - Suivi des Travaux (réalisés par le Concessionnaire) (15 mois)** | 315d | 2027-12-17 | 2029-03-01 |  | 0d |
| 30 | 1.3.1 | Phase Travaux (13 mois) | 273d | 2027-12-17 | 2029-01-02 | 28 | 0d |
| 31 | 1.3.2 | Phase reception et levée de réserves (2 mois) | 42d | 2029-01-03 | 2029-03-01 | 30 | 0d |
| 32 | 1.4 | **Phase 6 - Installation Mobilier / Equipements et Mise en service (1 mois)** | 21d | 2029-03-02 | 2029-03-30 |  | 0d |
| 33 | 1.4.1 | Installation mobilier equipements et mise en service | 20d | 2029-03-02 | 2029-03-29 | 31 | 0d |
| 34 | 1.4.2 | Ouverture de l'internat | 1d | 2029-03-30 | 2029-03-30 | 33 | 0d |
